# PISTA RIMAC

Schedule from MS Project, 2022-09-01 to 2022-10-30.

## Calendars

- Copia de Copia de Estándar: Mon-Sun 08:00-16:00.

## Resources

| Resource |
| --- |
| 14cc |
| 16cc+2 |

## Schedule

| ID | WBS | Task | Type | Duration | Start | Finish | Predecessors | Total slack | Cost |
| --- | --- | --- | --- | --- | --- | --- | --- | --- | --- |
| 1 | 1 | **OBRAS PROVISIONALES, TRABAJOS PRELIMINARES, SEGURIDAD Y SALUD** |  | 60d | 2022-09-01 | 2022-10-30 |  | 0d | 66,372.35 |
| 2 | 1.1 | **OBRAS PROVISIONALES** |  | 36d | 2022-09-01 | 2022-10-06 |  | 0d | 10,179.65 |
| 3 | 1.1.1 | CARTEL DE IDENTIFICACION DE OBRAS 4.80M X 3.60 M | manual | 1d | 2022-09-01 | 2022-09-01 |  |  | 1,734.76 |
| 4 | 1.1.2 | ALMACEN Y VESTUARIO Y OFICINA PROVISIONAL | manual | 2d | 2022-09-01 | 2022-10-06 | 3SS |  | 2,400 |
| 5 | 1.1.3 | ALQUILER DE BAÑOS PORTATILES PARA OBRA | manual | 2d | 2022-09-01 | 2022-10-06 | 4SS |  | 1,400 |
| 6 | 1.1.4 | MOVILIZACIÓN Y DESMOVILIZACIÓN DE MAQUINARIAS, EQUIPOS Y HERRAMIENTAS | manual | 6d | 2022-09-01 | 2022-09-06 | 5SS |  | 4,644.89 |
| 7 | 1.2 | **SEGURIDAD Y SALUD EN OBRA** |  | 60d | 2022-09-01 | 2022-10-30 |  | 0d | 10,825.85 |
| 8 | 1.2.1 | ELABORACION, IMPLEMENTACION Y ADMINISTRACION DEL PLAN DE SEGURIDAD Y SALUD EN EL TRABAJO | manual | 7d | 2022-09-01 | 2022-09-07 |  |  | 4,000 |
| 9 | 1.2.2 | EQUIPOS DE PROTECCION INDIVIDUAL | manual | 7d | 2022-09-01 | 2022-09-07 | 8SS |  | 2,149.2 |
| 10 | 1.2.3 | EQUIPOS DE PROTECCION COLECTIVA | manual | 7d | 2022-09-01 | 2022-09-07 | 9SS |  | 1,841 |
| 11 | 1.2.4 | CAPACITACION EN SEGURIDAD Y SALUD | manual | 60d | 2022-09-01 | 2022-10-30 | 10SS |  | 1,270 |
| 12 | 1.2.5 | RECURSOS PARA RESPUESTAS ANTE EMERGENCIAS EN SEGURIDAD Y SALUD | manual | 7d | 2022-09-01 | 2022-09-07 | 11SS |  | 1,565.65 |
| 13 | 1.3 | **TRABAJOS PRELIMINARES** |  | 16d | 2022-09-01 | 2022-09-16 |  | 0d | 45,366.85 |
| 14 | 1.3.1 | **DEMOLICIONES** |  | 16d | 2022-09-01 | 2022-09-16 |  | 0d | 40,833.84 |
| 15 | 1.3.1.1 | DEMOLICION DE VEREDA DE CONCRETO E =0.10 m | manual | 9d | 2022-09-01 | 2022-09-09 | 12SS |  | 9,229.67 |
| 16 | 1.3.1.2 | DEMOLICION DE RAMPA DE CONCRETO E=10 CM | manual | 9d | 2022-09-01 | 2022-09-09 | 12SS |  | 3,603.94 |
| 17 | 1.3.1.3 | DEMOLICION DE PISO DE MAYOLICA | manual | 9d | 2022-09-01 | 2022-09-09 | 12SS |  | 459.22 |
| 18 | 1.3.1.4 | DEMOLICION DE SARDINEL PERALTADO | manual | 1d | 2022-09-01 | 2022-09-01 | 15SS, 17SS, 16SS |  | 2,820.27 |
| 19 | 1.3.1.5 | DEMOLICIÓN DE SARDINEL SUMERGIDO | manual | 4d | 2022-09-02 | 2022-09-05 | 18 |  | 5,251.91 |
| 20 | 1.3.1.6 | CORTE DE PAVIMENTO EXISTENTE | manual | 1d | 2022-09-06 | 2022-09-06 | 19 |  | 263.36 |
| 21 | 1.3.1.7 | DEMOLICIÓN DE PAVIMENTO EXISTENTE | manual | 9d | 2022-09-07 | 2022-09-15 | 20 |  | 11,063.81 |
| 22 | 1.3.1.8 | ELIMINACION DE MATERIAL EXCEDENTE C/VOLQUETE DE 15M3 (D=10KM) | manual | 1d | 2022-09-16 | 2022-09-16 | 21 |  | 8,141.66 |
| 23 | 1.3.2 | **TRAZO Y REPLANTEO** |  | 6d | 2022-09-01 | 2022-09-06 |  | 0d | 4,533.01 |
| 24 | 1.3.2.1 | TRAZO Y REPLANTEO PRELIMINAR EN TERRENO NORMAL | manual | 6d | 2022-09-01 | 2022-09-06 | 15SS, 17SS, 16SS |  | 4,533.01 |

| ID | WBS | Task | Type | Duration | Start | Finish | Predecessors | Total slack | Cost |
| --- | --- | --- | --- | --- | --- | --- | --- | --- | --- |
| 25 | 2 | **VEREDA DE CONCRETO** |  | 30d | 2022-09-07 | 2022-10-06 |  | 0d | 68,442.48 |
| 26 | 2.1 | **MOVIMIENTO DE TIERRAS** |  | 17d | 2022-09-07 | 2022-09-23 |  | 0d | 21,100.46 |
| 27 | 2.1.1 | CORTE EN TERRENO NORMAL C/MAQUINARIA | manual | 1d | 2022-09-07 | 2022-09-07 | 24 |  | 943.13 |
| 28 | 2.1.2 | PERFILADO Y COMPACTACION DE TERRENO NATURAL | manual | 7d | 2022-09-08 | 2022-09-14 | 27 |  | 7,348.31 |
| 29 | 2.1.3 | RELLENO Y COMPACTADO CON MATERIAL PROPIO, C/ EQUIPO | manual | 1d | 2022-09-15 | 2022-09-15 | 28 |  | 632.47 |
| 30 | 2.1.4 | ELIMINACION DE MATERIAL EXCEDENTE C/VOLQUETE DE 15M3 (D=10KM) | manual | 1d | 2022-09-16 | 2022-09-16 | 29 |  | 2,316.21 |
| 31 | 2.1.5 | AFIRMADO DE E=10CM, NIVELADO Y COMPACTADO | manual | 7d | 2022-09-17 | 2022-09-23 | 30 |  | 9,860.34 |
| 32 | 2.2 | **OBRAS DE CONCRETO** |  | 13d | 2022-09-24 | 2022-10-06 |  | 0d | 34,488.19 |
| 33 | 2.2.1 | ENCOFRADO Y DESENCOFRADO DE VEREDAS DE CONCRETO | manual | 6d | 2022-09-24 | 2022-09-29 | 31 |  | 3,910.8 |
| 34 | 2.2.2 | VEREDA DE CONCRETO FC= 175 KG /CM2 (ACAB. SEMI PULIDO) | manual | 7d | 2022-09-24 | 2022-09-30 | 33FS-6d |  | 21,984.03 |
| 35 | 2.2.3 | CONCRETO f'c = 175 kg/cm² para Uñas en Veredas | manual | 2d | 2022-09-24 | 2022-09-25 | 34SS |  | 3,351.53 |
| 36 | 2.2.4 | CURADO CON ADITIVO QUIMICO EN CONCRETO | manual | 4d | 2022-09-26 | 2022-09-29 | 35 |  | 1,532.59 |
| 37 | 2.2.5 | JUNTA DE DILATACIÓN ASFALTO - ARENA 1:3, E=1"-VEREDAS | manual | 1d | 2022-09-30 | 2022-09-30 | 36 |  | 2,023.15 |
| 38 | 2.2.6 | BRUÑAS DE 1CM EN VEREDAS Y RAMPAS | manual | 7d | 2022-09-30 | 2022-10-06 | 36 |  | 1,686.09 |
| 39 | 2.3 | **NIVELACIÓN DE CAJAS DE AGUA Y DESAGUE** |  | 5d | 2022-09-24 | 2022-09-28 |  | 0d | 12,853.83 |
| 40 | 2.3.1 | NIVELACIÓN DE CAJAS DE AGUA | manual | 5d | 2022-09-24 | 2022-09-28 | 31 |  | 6,423.9 |
| 41 | 2.3.2 | NIVELACIÓN DE CAJAS DE DESAGÜE | manual | 3d | 2022-09-24 | 2022-09-26 | 31 |  | 6,429.93 |
| 42 | 3 | **MARTILLOS DE CONCRETO** |  | 20d | 2022-09-07 | 2022-09-26 |  | 0d | 12,043.33 |
| 43 | 3.1 | **MOVIMIENTO DE TIERRAS** |  | 11d | 2022-09-07 | 2022-09-17 |  | 0d | 4,707.59 |
| 44 | 3.1.1 | CORTE EN TERRENO NORMAL C/MAQUINARIA | manual | 1d | 2022-09-07 | 2022-09-07 | 24 |  | 210.38 |
| 45 | 3.1.2 | PERFILADO Y COMPACTACION DE TERRENO NATURAL | manual | 4d | 2022-09-08 | 2022-09-11 | 44 |  | 1,639.43 |
| 46 | 3.1.3 | RELLENO Y COMPACTADO CON MATERIAL PROPIO, C/ EQUIPO | manual | 1d | 2022-09-12 | 2022-09-12 | 45 |  | 141.1 |
| 47 | 3.1.4 | ELIMINACION DE MATERIAL EXCEDENTE C/VOLQUETE DE 15M3 (D=10KM) | manual | 1d | 2022-09-13 | 2022-09-13 | 46 |  | 516.82 |
| 48 | 3.1.5 | AFIRMADO DE E=10CM, NIVELADO Y COMPACTADO | manual | 4d | 2022-09-14 | 2022-09-17 | 47 |  | 2,199.86 |

| ID | WBS | Task | Type | Duration | Start | Finish | Predecessors | Total slack | Cost |
| --- | --- | --- | --- | --- | --- | --- | --- | --- | --- |
| 49 | 3.2 | **OBRAS DE CONCRETO** |  | 9d | 2022-09-18 | 2022-09-26 |  | 0d | 7,335.74 |
| 50 | 3.2.1 | ENCOFRADO Y DESENCOFRADO DE MARTILLOS DE CONCRETO | manual | 4d | 2022-09-18 | 2022-09-21 | 48 |  | 872.32 |
| 51 | 3.2.2 | MARTILLO DE CONCRETO FC= 175 KG /CM2 (ACAB. SEMI PULIDO) | manual | 4d | 2022-09-19 | 2022-09-22 | 50FS-3d |  | 4,904.69 |
| 52 | 3.2.3 | CONCRETO F'C = 175 kg/cm² ´PARA UÑAS EN MARTILLOS | manual | 1d | 2022-09-19 | 2022-09-19 | 51SS |  | 746.25 |
| 53 | 3.2.4 | CURADO CON ADITIVO QUIMICO EN CONCRETO | manual | 2d | 2022-09-23 | 2022-09-24 | 51 |  | 341.92 |
| 54 | 3.2.5 | BRUÑAS DE 1CM EN VEREDAS Y RAMPAS | manual | 4d | 2022-09-23 | 2022-09-26 | 51 |  | 470.56 |
| 55 | 4 | **BERMAS DE CONCRETO** |  | 12d | 2022-09-07 | 2022-09-18 |  | 0d | 33,581.23 |
| 56 | 4.1 | **MOVIMIENTO DE TIERRAS** |  | 7d | 2022-09-07 | 2022-09-13 |  | 0d | 14,601.77 |
| 57 | 4.1.1 | CORTE EN TERRENO NORMAL C/MAQUINARIA | manual | 1d | 2022-09-07 | 2022-09-07 | 24 |  | 652.71 |
| 58 | 4.1.2 | PERFILADO Y COMPACTACION DE TERRENO NATURAL | manual | 2d | 2022-09-08 | 2022-09-09 | 57 |  | 5,085.09 |
| 59 | 4.1.3 | RELLENO Y COMPACTADO CON MATERIAL PROPIO, C/ EQUIPO | manual | 1d | 2022-09-10 | 2022-09-10 | 58 |  | 437.77 |
| 60 | 4.1.4 | ELIMINACION DE MATERIAL EXCEDENTE C/VOLQUETE DE 15M3 (D=10KM) | manual | 1d | 2022-09-11 | 2022-09-11 | 59 |  | 1,602.77 |
| 61 | 4.1.5 | AFIRMADO DE E=10CM, NIVELADO Y COMPACTADO | manual | 2d | 2022-09-12 | 2022-09-13 | 60 |  | 6,823.43 |
| 62 | 4.2 | **OBRAS DE CONCRETO** |  | 5d | 2022-09-14 | 2022-09-18 |  | 0d | 18,979.46 |
| 63 | 4.2.1 | BERMA DE CONCRETO FC= 175 KG /CM2 (ACAB. SEMI PULIDO) | manual | 2d | 2022-09-14 | 2022-09-15 | 61 |  | 15,213.12 |
| 64 | 4.2.2 | CURADO CON ADITIVO QUIMICO EN CONCRETO | manual | 1d | 2022-09-16 | 2022-09-16 | 63 |  | 1,060.56 |
| 65 | 4.2.3 | BRUÑAS DE 1CM EN VEREDAS Y RAMPAS | manual | 2d | 2022-09-17 | 2022-09-18 | 64 |  | 2,705.78 |
| 66 | 5 | **SARDINELES** |  | 33d | 2022-09-19 | 2022-10-21 |  | 0d | 54,333.68 |
| 67 | 5.1 | **SARDINEL PERALTADO PARA JARDINERAS H=0.60M** |  | 20d | 2022-09-19 | 2022-10-08 |  | 0d | 31,591.52 |
| 68 | 5.1.1 | **MOVIMIENTO DE TIERRAS** |  | 4d | 2022-09-19 | 2022-09-22 |  | 0d | 837.81 |
| 69 | 5.1.1.1 | CORTE DE TERRENO MANUAL | manual | 2d | 2022-09-19 | 2022-09-20 | 65 |  | 460.42 |
| 70 | 5.1.1.2 | RELLENO Y COMPACTACION CON MATERIAL PROPIO SELECCIONADO PARA SARDINELES | manual | 1d | 2022-09-21 | 2022-09-21 | 69 |  | 133.38 |
| 71 | 5.1.1.3 | ELIMINACION DE MATERIAL EXCEDENTE C/VOLQUETE DE 15M3 (D=10KM) | manual | 1d | 2022-09-22 | 2022-09-22 | 70 |  | 244.01 |
| 72 | 5.1.2 | **OBRAS DE CONCRETO ARMADO** |  | 16d | 2022-09-23 | 2022-10-08 |  | 0d | 30,753.71 |
| 73 | 5.1.2.1 | ACERO DE REFUERZO fy = 4200 kg/cm², GRADO 60 | manual | 3d | 2022-10-01 | 2022-10-03 | 74 |  | 5,468.19 |
| 74 | 5.1.2.2 | ENCOFRADO Y DESENCOFRADO DE SARDINEL PERALTADO | manual | 8d | 2022-09-23 | 2022-09-30 | 71 |  | 10,883.03 |
| 75 | 5.1.2.3 | CONCRETO F'C=210KM/CM2 CON PREPARACION MANUAL PARA JARDINERA H=0.60M | manual | 2d | 2022-10-04 | 2022-10-05 | 73 |  | 9,399.46 |
| 76 | 5.1.2.4 | CURADO CON ADITIVO QUIMICO EN CONCRETO | manual | 1d | 2022-10-06 | 2022-10-06 | 75 |  | 968.7 |
| 77 | 5.1.2.5 | JUNTA DE DILATACIÓN ASFALTO - ARENA 1:3, E=1"-SARDINELES | manual | 1d | 2022-10-07 | 2022-10-07 | 76 |  | 568.34 |
| 78 | 5.1.2.6 | PINTURA DE SARDINEL | manual | 1d | 2022-10-08 | 2022-10-08 | 77 |  | 3,465.99 |

| ID | WBS | Task | Type | Duration | Start | Finish | Predecessors | Total slack | Cost |
| --- | --- | --- | --- | --- | --- | --- | --- | --- | --- |
| 79 | 5.2 | **SARDINEL SUMERGIDO PARA CONFINAMIENTO DE PISTA H=0.40M** |  | 33d | 2022-09-19 | 2022-10-21 |  | 0d | 22,742.16 |
| 80 | 5.2.1 | **MOVIMIENTO DE TIERRAS** |  | 7d | 2022-09-19 | 2022-09-25 |  | 0d | 1,317.17 |
| 81 | 5.2.1.1 | CORTE DE TERRENO MANUAL | manual | 5d | 2022-09-19 | 2022-09-23 | 65 |  | 724.01 |
| 82 | 5.2.1.2 | RELLENO Y COMPACTACION CON MATERIAL PROPIO SELECCIONADO PARA SARDINELES | manual | 1d | 2022-09-24 | 2022-09-24 | 81 |  | 209.41 |
| 83 | 5.2.1.3 | ELIMINACION DE MATERIAL EXCEDENTE C/VOLQUETE DE 15M3 (D=10KM) | manual | 1d | 2022-09-25 | 2022-09-25 | 82 |  | 383.75 |
| 84 | 5.2.2 | **OBRAS DE CONCRETO SIMPLE** |  | 14d | 2022-10-08 | 2022-10-21 |  | 0d | 21,424.99 |
| 85 | 5.2.2.1 | ENCOFRADO Y DESENCOFRADO DE SARDINEL SUMERGIDO | manual | 7d | 2022-10-08 | 2022-10-14 | 94 |  | 10,545 |
| 86 | 5.2.2.2 | CONCRETO F'C=175KM/CM2 CON PREPARACION MANUAL PARA SARDINEL SUMERGIDO H=0.40M | manual | 4d | 2022-10-15 | 2022-10-18 | 85 |  | 9,808.37 |
| 87 | 5.2.2.3 | CURADO CON ADITIVO QUIMICO EN CONCRETO | manual | 3d | 2022-10-19 | 2022-10-21 | 86 |  | 1,071.62 |
| 88 | 6 | **PAVIMENTO FLEXIBLE** |  | 31d | 2022-09-27 | 2022-10-27 |  | 0d | 140,545.37 |
| 89 | 6.1 | **MOVIMIENTO DE TIERRAS** |  | 6d | 2022-09-27 | 2022-10-02 |  | 0d | 22,543.98 |
| 90 | 6.1.1 | CORTE A NIVEL DE SUBRASANTE C/MAQUINARIA | manual | 3d | 2022-09-27 | 2022-09-29 | 54 |  | 5,880.42 |
| 91 | 6.1.2 | ELIMINACION DE MATERIAL EXCEDENTE C/VOLQUETE DE 15M3 (D=10KM) | manual | 3d | 2022-09-30 | 2022-10-02 | 90 |  | 16,663.56 |
| 92 | 6.2 | **PAVIMENTACION** |  | 17d | 2022-10-03 | 2022-10-19 |  | 0d | 103,604.23 |
| 93 | 6.2.1 | CONFORMACION DE SUBRASANTE CON EQUIPO PESADO | manual | 2d | 2022-10-03 | 2022-10-04 | 91 |  | 4,412.6 |
| 94 | 6.2.2 | SUB BASE GRANULAR E=0.10 m CON EQUIPO PESADO | manual | 2d | 2022-10-05 | 2022-10-06 | 93 |  | 13,111.74 |
| 95 | 6.2.3 | BASE GRANULAR E=0.20 m CON EQUIPO PESADO | manual | 7d | 2022-10-07 | 2022-10-13 | 94 |  | 31,970.37 |
| 96 | 6.2.4 | IMPRIMACIÓN ASFÁLTICA | manual | 2d | 2022-10-14 | 2022-10-15 | 95 |  | 6,177.65 |
| 97 | 6.2.5 | CARPETA ASFALTICA EN CALIENTE E=2" C/EQUIPO | manual | 4d | 2022-10-16 | 2022-10-19 | 96 |  | 47,931.87 |
| 98 | 6.3 | **SEÑALIZACIÓN** |  | 8d | 2022-10-20 | 2022-10-27 |  | 0d | 10,246.23 |
| 99 | 6.3.1 | PINTURA LINEAL CONTINUA E=0.15 M | manual | 5d | 2022-10-20 | 2022-10-24 | 97 |  | 4,706.23 |
| 100 | 6.3.2 | PINTURA LINEAL DISCONTINUA E=0.15 M | manual | 5d | 2022-10-20 | 2022-10-24 | 97 |  | 2,450.29 |
| 101 | 6.3.3 | SEÑALIZACION HORIZONTAL | manual | 3d | 2022-10-25 | 2022-10-27 | 100 |  | 3,089.71 |
| 102 | 6.4 | **NIVELACIÓN DE BUZONES DE DESAGÜE** |  | 2d | 2022-10-06 | 2022-10-07 |  | 0d | 4,150.93 |
| 103 | 6.4.1 | NIVELACION DE TECHOS DE BUZONES A NIVEL DE RASANTE | manual | 2d | 2022-10-06 | 2022-10-07 | 93 |  | 4,150.93 |

| ID | WBS | Task | Type | Duration | Start | Finish | Predecessors | Total slack | Cost |
| --- | --- | --- | --- | --- | --- | --- | --- | --- | --- |
| 104 | 7 | **PAISAJISMO** |  | 5d | 2022-10-09 | 2022-10-13 |  | 0d | 3,054.55 |
| 105 | 7.1 | **MOVIMIENTO DE TIERRAS** |  | 3d | 2022-10-09 | 2022-10-11 |  | 0d | 765.62 |
| 106 | 7.1.1 | CORTE DE TERRENO MANUAL | manual | 2d | 2022-10-09 | 2022-10-10 | 78 |  | 371.69 |
| 107 | 7.1.2 | ELIMINACION DE MATERIAL EXCEDENTE C/VOLQUETE DE 15M3 (D=10KM) | manual | 1d | 2022-10-11 | 2022-10-11 | 106 |  | 393.93 |
| 108 | 7.2 | **JARDINERÍA** |  | 2d | 2022-10-12 | 2022-10-13 |  | 0d | 2,288.93 |
| 109 | 7.2.1 | SUMINISTRO E INSTALACION DE TIERRA DE CHACRA | manual | 1d | 2022-10-12 | 2022-10-12 | 107 |  | 814.96 |
| 110 | 7.2.2 | SUMINISTRO E INSTALACION DE GRASS AMERICANO | manual | 1d | 2022-10-13 | 2022-10-13 | 109 |  | 1,473.97 |
| 111 | 8 | **ACARREO DE MATERIALES** |  | 57d | 2022-09-01 | 2022-10-27 |  | 0d | 10,127.8 |
| 112 | 8.1 | ACARREO DE MATERIAL PROCEDENTE DE EXCAVACIONES O RELLENOS PARA SER ELIMINADO | manual | 30d | 2022-09-01 | 2022-10-27 | 3SS |  | 10,127.8 |
| 113 | 9 | **PLAN DE MANEJO AMBIENTAL** |  | 59d | 2022-09-01 | 2022-10-29 |  | 0d | 12,191.74 |
| 114 | 9.1 | PLAN DE MITIGACIÓN AMBIENTAL DURANTE OBRA | manual | 7d | 2022-09-01 | 2022-09-07 | 3SS |  | 6,272.42 |
| 115 | 9.2 | RIEGO DURANTE LA EJECUCION | manual | 30d | 2022-09-01 | 2022-10-29 |  |  | 5,919.32 |
| 116 | 10 | **VARIOS** |  | 3d | 2022-10-28 | 2022-10-30 |  | 0d | 5,908.03 |
| 117 | 10.1 | LIMPIEZA FINAL DE OBRA | manual | 1d | 2022-10-30 | 2022-10-30 | 118 |  | 4,709.05 |
| 118 | 10.2 | SUMINISTRO E INSTALACION DE PEDESTAL CON PLACA RECORDATORIA DE LA OBRA | manual | 2d | 2022-10-28 | 2022-10-29 | 101 |  | 1,198.98 |
